# ERS Project Schedule

Schedule from MS Project, 2004-03-02 to 2006-09-28, costs in $, A marks actual dates.
University of California

## Calendars

- Standard: Mon-Fri 08:00-12:00, 13:00-17:00; Sat-Sun off.

## Resources

| Resource | Rate |
| --- | --- |
| PM | 95 |
| P1 | 95 |
| P2 | 90 |
| P3 | 90 |
| D1 | 75 |
| P4 | 95 |

## Schedule

| ID | WBS | Task | Duration | Start | Finish | Predecessors | Complete | Constraint | Resources | Work | Actual work | Cost | Actual cost | Text2 | Text8 | Text30 |
| --- | --- | --- | --- | --- | --- | --- | --- | --- | --- | --- | --- | --- | --- | --- | --- | --- |
| 1 | 1 | **Start-up** | 112d | 2004-03-28 A | 2004-08-31 A |  | 100% |  |  |  |  |  |  |  |  |  |
| 2 | 1.1 | Identify Project Manager | 43d | 2004-03-28 A | 2004-05-26 A |  | 100% | finish no earlier than 2003-11-30 |  |  |  |  |  |  |  |  |
| 3 | 1.2 | Identify Liaison | 112d | 2004-03-28 A | 2004-08-31 A |  | 100% | finish no earlier than 2004-08-31 |  |  |  |  |  |  |  |  |
| 4 | 1.3 | Identify other staff for start | 85d | 2004-04-26 A | 2004-08-20 A |  | 100% | finish no earlier than 2004-08-20 |  |  |  |  |  |  |  |  |
| 6 | 2 | **Architecture/Design** | 275d? | 2004-08-02 A | 2005-08-19 A |  | 100% |  |  | 4157.6h | 4157.6h | 374,460 | 374,460 |  |  |  |
| 7 | 2.1 | Effort Report - format and content | 101d | 2004-08-02 A | 2004-12-20 A |  | 100% | finish no earlier than 2004-11-18 |  |  |  |  |  |  |  |  |
| 8 | 2.2 | **Application Model** | 268d | 2004-08-11 A | 2005-08-19 A |  | 100% |  | P1 | 2048h | 2048h | 194,560 | 194,560 | 160 |  |  |
| 9 | 2.2.1 | Security and roles processing | 30d | 2004-08-11 A | 2004-09-21 A |  | 100% | start no earlier than 2004-07-26 |  |  |  |  |  |  |  |  |
| 10 | 2.2.2 | Audit | 15d | 2004-09-22 A | 2004-10-12 A | 9 | 100% |  |  |  |  |  |  |  |  |  |
| 11 | 2.2.3 | Reporting Period Processing | 40d | 2004-10-25 A | 2004-12-17 A | 10 | 100% |  |  |  |  |  |  |  |  |  |
| 12 | 2.2.4 | Effort Report Generation | 30d | 2004-10-25 A | 2004-12-21 A | 11 | 100% | start no earlier than 2004-07-19 |  |  |  |  |  |  |  |  |
| 13 | 2.2.5 | Notification services | 15d | 2005-05-01 A | 2005-05-20 A | 12 | 100% |  |  |  |  |  |  |  |  |  |
| 14 | 2.2.6 | Administrative functions | 20d | 2005-05-23 A | 2005-06-17 A | 13 | 100% |  |  |  |  |  |  |  |  |  |
| 15 | 2.2.7 | Authentication Interface | 25d | 2005-06-20 A | 2005-07-22 A | 14 | 100% |  |  |  |  |  |  |  |  |  |
| 16 | 2.2.8 | Authorization Interface | 5d | 2005-06-20 A | 2005-06-24 A | 14 | 100% |  |  |  |  |  |  |  |  |  |
| 17 | 2.2.9 | E-Mail System Interface | 10d | 2005-07-25 A | 2005-08-05 A | 16 | 100% | start no earlier than 2005-03-06 |  |  |  |  |  |  |  |  |
| 18 | 2.2.10 | Transaction logging function | 5d | 2005-08-08 A | 2005-08-12 A | 17 | 100% |  |  |  |  |  |  |  | 16 | Added to version 2: ERS_Project_Schedule.mpp |
| 19 | 2.2.11 | Crash/Diagnostic logging function | 5d | 2005-08-15 A | 2005-08-19 A | 18 | 100% |  |  |  |  |  |  |  | 17 | Added to version 2: ERS_Project_Schedule.mpp |
| 20 | 2.3 | **Database Design** | 107d | 2004-10-05 A | 2005-03-02 A |  | 100% |  | P3 | 1384h | 1384h | 125,480 | 125,480 | 480 |  |  |
| 21 | 2.3.1 | Database designer begins | 1d | 2004-10-05 A | 2004-10-05 A |  | 100% | finish no earlier than 2004-09-27 |  |  |  |  |  |  |  |  |
| 22 | 2.3.2 | Data schema design | 40d | 2004-11-03 A | 2004-12-28 A | 21 | 100% |  |  |  |  |  |  |  |  |  |
| 23 | 2.3.3 | Data element definitions | 30d | 2004-12-29 A | 2005-02-08 A | 22 | 100% | start no earlier than 2004-08-09 |  |  |  |  |  |  |  |  |
| 24 | 2.3.4 | DBMS compatibility testing | 5d | 2005-02-09 A | 2005-02-15 A | 23 | 100% |  |  |  |  |  |  |  |  |  |
| 25 | 2.3.5 | Index design | 8d | 2005-02-16 A | 2005-02-25 A | 24 | 100% |  |  |  |  |  |  |  |  |  |
| 26 | 2.3.6 | Publish sizing guidelines | 2d | 2005-02-28 A | 2005-03-01 A | 25 | 100% |  |  |  |  |  |  |  |  |  |

| ID | WBS | Task | Duration | Start | Finish | Predecessors | Complete | Constraint | Resources | Work | Actual work | Cost | Actual cost | Text2 |
| --- | --- | --- | --- | --- | --- | --- | --- | --- | --- | --- | --- | --- | --- | --- |
| 27 | 2.3.7 | **Data Interfaces** | 43d | 2005-01-02 A | 2005-03-02 A |  | 100% |  | P1; P2 | 528h | 528h | 48,440 | 48,440 | 640 |
| 28 | 2.3.7.1 | PPS Extract Interface | 15d | 2005-01-02 A | 2005-01-21 A | 22 | 100% |  |  |  |  |  |  |  |
| 29 | 2.3.7.2 | Financial System Interface | 10d | 2005-01-24 A | 2005-02-28 A | 28 | 100% |  |  |  |  |  |  |  |
| 30 | 2.3.7.3 | Contracts & Grants Interface | 15d | 2005-01-24 A | 2005-03-01 A | 29 | 100% |  |  |  |  |  |  |  |
| 31 | 2.3.7.4 | Cost Sharing Interface | 10d | 2005-01-24 A | 2005-03-02 A | 30 | 100% |  |  |  |  |  |  |  |
| 32 | 2.3.8 | Data Interface-Reformat/Load | 30d | 2004-12-29 A | 2005-02-08 A | 22 | 100% |  |  |  |  |  |  |  |
| 33 | 2.3.9 | Database Design Review (Technical Advisory Sub-Group) | 1d | 2005-01-18 A | 2005-01-18 A |  | 100% | start no earlier than 2005-01-18 |  |  |  |  |  |  |
| 34 | 2.3.10 | Test Case Review (Requirements Sub-Group) | 1d | 2005-02-10 A | 2005-02-10 A |  | 100% | start no earlier than 2005-02-10 |  |  |  |  |  |  |
| 35 | 2.3.11 | Test Case Review (Management Group) | 1d | 2005-02-17 A | 2005-02-17 A |  | 100% | start no earlier than 2005-02-09 |  |  |  |  |  |  |
| 36 | 2.4 | **Presentation Design - User** | 90.7d? | 2004-11-22 A | 2005-03-28 A |  | 100% |  | D1 | 725.6h | 725.6h | 54,420 | 54,420 | 320 |
| 37 | 2.4.1 | Web UI designer begins | 1d | 2004-11-22 A | 2004-11-22 A |  | 100% | start no earlier than 2004-10-25 |  |  |  |  |  |  |
| 38 | 2.4.2 | Preliminary user interface design | 38d | 2004-11-22 A | 2005-01-12 A |  | 100% | finish no earlier than 2005-01-12 |  |  |  |  |  |  |
| 39 | 2.4.3 | Preliminary design review | 1d | 2005-01-13 A | 2005-01-13 A | 38 | 100% |  |  |  |  |  |  |  |
| 40 | 2.4.4 | Revise design - incorporate feedback | 30d | 2005-01-14 A | 2005-02-24 A | 39 | 100% | start no earlier than 2005-01-14 |  |  |  |  |  |  |
| 41 | 2.4.5 | Publish browser standards | 3d | 2005-02-25 A | 2005-03-01 A | 40 | 100% | start no earlier than 2005-04-01 |  |  |  |  |  |  |
| 42 | 2.4.6 | Multi-line certification | 6d | 2005-02-25 A | 2005-03-09 A | 41 | 100% |  |  |  |  |  |  |  |
| 43 | 2.4.7 | Online help | 8d | 2005-03-09 A | 2005-03-21 A | 42 | 100% |  |  |  |  |  |  |  |
| 44 | 2.4.8 | Common functions (print/email/export) | 2d | 2005-03-21 A | 2005-03-23 A | 43 | 100% |  |  |  |  |  |  |  |
| 45 | 2.4.9 | Revised design review | 1d? | 2005-03-23 A | 2005-03-24 A | 44 | 100% | start no earlier than 2005-02-10 |  |  |  |  |  |  |
| 46 | 2.4.10 | Page flow design | 2d | 2005-03-24 A | 2005-03-28 A | 45 | 100% |  |  |  |  |  |  |  |
| 47 | 2.5 | **Presentation Design - Administration** | 15d | 2005-04-07 A | 2005-04-28 A | 46SS+10d | 100% |  |  |  |  |  |  | 640 |
| 48 | 2.5.1 | System administration - preliminary | 5d | 2005-04-07 A | 2005-04-14 A | 45FS+5d | 100% | start no earlier than 2004-09-01 |  |  |  |  |  |  |
| 49 | 2.5.2 | System administration - revised | 10d | 2005-04-14 A | 2005-04-28 A | 48 | 100% |  |  |  |  |  |  |  |
| 50 | 2.6 | Training-Design Phase | 21d? | 2005-07-13 A | 2005-08-10 A |  | 100% | finish no earlier than 2005-08-05 |  |  |  |  |  |  |

| ID | WBS | Task | Type | Duration | Start | Finish | Predecessors | Complete | Constraint | Text2 |
| --- | --- | --- | --- | --- | --- | --- | --- | --- | --- | --- |
| 52 | 3 | **Development** |  | 330d? | 2004-12-01 A | 2006-03-07 A |  | 100% |  |  |
| 53 | 3.1 | Establish development environment |  | 8d? | 2004-12-01 A | 2004-12-10 A |  | 100% | finish no earlier than 2004-12-10 |  |
| 54 | 3.2 | Common data layer |  | 20d | 2004-12-06 A | 2004-12-31 A |  | 100% |  |  |
| 55 | 3.3 | Hire Java Developer | milestone | 0d | 2005-02-11 A | 2005-02-11 A |  | 100% | start no earlier than 2005-03-01 |  |
| 56 | 3.4 | **Data Interfaces** |  | 161d | 2004-12-06 A | 2005-07-18 A |  | 100% |  |  |
| 57 | 3.4.1 | PPS Interface - coding & unit testing |  | 10d | 2004-12-06 A | 2004-12-17 A |  | 100% |  | 160 |
| 58 | 3.4.2 | Departments interface - code & unit testing |  | 10d | 2005-02-14 A | 2005-02-25 A | 57, 55SS | 100% |  | 160 |
| 59 | 3.4.3 | Fund/Grant Interface - coding & unit testing |  | 20d | 2005-02-28 A | 2005-03-25 A | 58 | 100% |  | 160 |
| 60 | 3.4.4 | ERS/PPS Interface - code & unit testing |  | 50d | 2005-03-28 A | 2005-06-03 A | 59 | 100% |  | 160 |
| 61 | 3.4.5 | Cost Sharing Interface - code & unit testing |  | 20d | 2005-06-06 A | 2005-07-04 A | 60 | 100% |  | 160 |
| 62 | 3.4.6 | User Interface - code & unit testing |  | 10d | 2005-07-05 A | 2005-07-18 A | 61 | 100% |  |  |
| 63 | 3.4.7 | Interface Load Processing (ILP) (common) |  | 20d | 2005-03-01 A | 2005-03-28 A |  | 100% |  | 480 |
| 64 | 3.5 | **Batch Processing** |  | 119d | 2005-03-01 A | 2005-08-12 A |  | 100% |  |  |
| 65 | 3.5.1 | Report Period Initiation (RPI) |  | 40d | 2005-03-01 A | 2005-04-25 A |  | 100% |  |  |
| 66 | 3.5.2 | Generate (rollup and calculation) (GEN) |  | 35d | 2005-04-25 A | 2005-06-10 A | 65 | 100% |  |  |
| 67 | 3.5.3 | Version Up (VUP) |  | 15d | 2005-06-13 A | 2005-07-01 A | 66 | 100% |  |  |
| 68 | 3.5.4 | Notification Event Capture |  | 10d | 2005-07-04 A | 2005-07-15 A | 67 | 100% | start no earlier than 2005-04-03 | 320 |
| 69 | 3.5.5 | Notification Generation and Distribution |  | 20d | 2005-07-18 A | 2005-08-12 A | 68 | 100% | start no earlier than 2005-05-13 | 160 |
| 70 | 3.6 | **Web Application** |  | 96d | 2005-04-01 A | 2005-08-12 A |  | 100% |  |  |
| 71 | 3.6.1 | WebApp - Signon |  | 5d | 2005-04-01 A | 2005-04-07 A |  | 100% | start no earlier than 2005-04-01 |  |
| 72 | 3.6.2 | WebApp - Report List |  | 5d | 2005-04-08 A | 2005-04-14 A | 71 | 100% | start no earlier than 2005-04-01 |  |
| 73 | 3.6.3 | WebApp - Report View/Edit |  | 10d | 2005-05-02 A | 2005-05-13 A | 72 | 100% | start no earlier than 2005-05-02 | 160 |
| 74 | 3.6.4 | WebApp - Report Item Detail |  | 10d | 2005-05-16 A | 2005-05-27 A | 73 | 100% |  |  |
| 75 | 3.6.5 | WebApp - Report Detail |  | 10d | 2005-05-30 A | 2005-06-10 A | 74 | 100% |  |  |
| 76 | 3.6.6 | WebApp - Define Search |  | 15d | 2005-06-13 A | 2005-07-01 A | 75 | 100% | start no earlier than 2005-04-08 | 480 |
| 77 | 3.6.7 | WebApp - Manage Lists |  | 10d | 2005-07-04 A | 2005-07-15 A | 76 | 100% |  |  |
| 78 | 3.6.8 | WebApp - Add Project |  | 10d | 2005-07-18 A | 2005-07-29 A | 77 | 100% |  |  |
| 79 | 3.6.9 | WebApp - Certify |  | 5d | 2005-08-01 A | 2005-08-05 A | 78 | 100% |  | 160 |
| 80 | 3.6.10 | WebApp - Multiple Certifications |  | 5d | 2005-08-08 A | 2005-08-12 A | 79 | 100% |  | 320 |
| 81 | 3.7 | Code Complete | milestone | 1d? | 2005-08-31 A | 2005-08-31 A |  | 100% | start no earlier than 2005-08-31 |  |

Notes:
- 56: Text1: Generic interfaces to local campus systems
- 57: Text1: Payroll Audit Record
- 59: Text1: (Security System)
- 60: Text1: Account/Fund Profile
- 61: Text1: (Security System)
- 63: Text1: Mechanism for collecting data on individuals who received no pay from a sponsored project
- 68: Text1: Mechanism for notifying individuals that effort reports are ready for pre-review, review/certification, or have been certified
- 69: Text1: Mechanism for providing reminders of needed reviews and certifications
- 73: Text1: Mechanism for changing effort detail on an individual effort report
- 76: Text1: Mechanism for locating effort reports (general search, role-based search, etc.)
- 79: Text1: Mechanism for certifying one effort report
- 80: Text1: Mechanism for certifying two or more effort reports at one time

| ID | WBS | Task | Type | Duration | Start | Finish | Predecessors | Complete | Constraint | Text2 |
| --- | --- | --- | --- | --- | --- | --- | --- | --- | --- | --- |
| 82 | 3.8 | **System Administration** |  | 117.5d | 2005-09-01 A | 2006-02-13 A |  | 100% |  |  |
| 83 | 3.8.1 | Authorization Rules |  | 5d | 2005-09-01 A | 2005-09-07 A |  | 100% | start no earlier than 2005-01-02 | 480 |
| 84 | 3.8.2 | Authorizaton Administration |  | 37d | 2005-09-08 A | 2005-10-28 A | 83 | 100% | finish no earlier than 2005-10-28 | 480 |
| 85 | 3.8.3 | System Administration |  | 30d | 2005-10-06 A | 2005-11-18 A | 84 | 100% |  |  |
| 86 | 3.8.4 | Compliance Monitoring Tools* |  | 10d | 2005-11-17 A | 2005-12-02 A | 85 | 100% |  | 640 |
| 87 | 3.8.5 | Control/Audit Reports* |  | 5d | 2005-12-02 A | 2005-12-09 A | 86 | 100% |  | 480 |
| 88 | 3.8.6 | General Reporting* |  | 1d | 2005-12-09 A | 2005-12-12 A | 87 | 100% |  | 960 |
| 89 | 3.8.7 | Ad Hoc Reporting* |  | 5d | 2005-12-12 A | 2005-12-19 A | 88 | 100% |  | 960 |
| 90 | 3.8.8 | Portal integration* |  | 30d | 2005-12-19 A | 2006-01-30 A | 89 | 100% |  |  |
| 91 | 3.8.9 | Data retention and archival |  | 10d | 2006-01-30 A | 2006-02-13 A | 90 | 100% |  |  |
| 92 | 3.9 | Publish customization specification and guide |  | 30d | 2006-01-03 A | 2006-02-13 A |  | 100% | finish no earlier than 2006-02-06 |  |
| 93 | 3.10 | Prepare default style and graphics |  | 5d | 2006-01-03 A | 2006-01-09 A |  | 100% |  |  |
| 94 | 3.11 | Training-Development Phase |  | 168d? | 2005-05-12 A | 2006-01-02 A |  | 100% | finish no earlier than 2006-01-02 |  |
| 95 | 3.12 | Training-Packaging |  | 27d? | 2006-01-30 A | 2006-03-07 A |  | 100% | finish no earlier than 2006-03-07 |  |
| 97 | 4 | **Testing** |  | 105d | 2005-08-15 A | 2006-01-06 A |  | 100% |  |  |
| 98 | 4.1 | Pre-QA Data Validation |  | 67d | 2005-08-15 A | 2005-11-15 A |  | 100% | finish no earlier than 2005-11-15 |  |
| 99 | 4.2 | Integration Testing |  | 12d | 2005-09-01 A | 2005-09-16 A |  | 100% | start no earlier than 2005-09-01 | 960 |
| 100 | 4.3 | QA Testing |  | 42d | 2005-09-19 A | 2005-11-15 A | 99 | 100% | finish no earlier than 2005-11-15 |  |
| 101 | 4.4 | Useability Testing |  | 30d | 2005-11-16 A | 2005-12-27 A | 100 | 100% | start no earlier than 2005-07-01 |  |
| 102 | 4.5 | Load/Stress Testing (transferred to maintenance schedule) |  | 320h | 2005-11-14 A | 2006-01-06 A | 100SS | 100% | start no earlier than 2005-11-13 | 320 |
| 104 | 5 | Training-Pilot Phase |  | 53d? | 2005-10-04 A | 2005-12-15 A |  | 100% | finish no earlier than 2005-12-15 |  |
| 105 | 6 | Pilot-Release | milestone | 66d | 2005-09-30 A | 2005-12-30 A |  | 100% | finish no earlier than 2005-12-30 |  |
| 106 | 7 | Pilot-Support and Bugfix |  | 87d? | 2005-10-03 A | 2006-01-31 A |  | 100% | finish no earlier than 2006-01-31 |  |
| 107 | 8 | Pre-Release | milestone | 1d | 2006-01-16 A | 2006-01-16 A |  | 100% | start no earlier than 2006-01-16 |  |

Notes:
- 83: Text1: Implementation of roles and associated permissions
- 84: Text1: Tool(s) for administration of roles and permissions
- 86: Text1: Reports for measuring current period compliance and comparing with historical periods
- 87: Text1: System-level controls and audit reports(e.g., system access reports, transaction statistics)
- 88: Text1: Standard reporting other than compliance/control/audit reporting (needs detailed definition)
- 89: Text1: (if other than third-party tools-based reporting)
- 102: Text1: Stress testing to determine system performance characteristics

| ID | WBS | Task | Type | Duration | Start | Finish | Predecessors | Complete | Constraint | Text2 |
| --- | --- | --- | --- | --- | --- | --- | --- | --- | --- | --- |
| 109 | 9 | **Deployment (Release to Campuses)** |  | 342d? | 2005-06-08 A | 2006-09-28 A |  | 100% |  |  |
| 110 | 9.1 | Documentation |  | 544h | 2005-09-08 A | 2005-12-12 A |  | 100% |  | 640 |
| 111 | 9.2 | Packaging |  | 160h | 2006-01-09 A | 2006-02-03 A |  | 100% | start no earlier than 2006-01-08 | 160 |
| 112 | 9.3 | Release 1 | milestone | 1d? | 2006-02-06 A | 2006-02-06 A | 111 | 100% |  |  |
| 113 | 9.4 | Release installation support (transferred to maintenance schedule) |  | 60d | 2006-02-07 A | 2006-05-01 A | 112 | 100% |  |  |
| 114 | 9.5 | Training-Deployment Phase |  | 2736h | 2005-06-08 A | 2006-09-28 A |  | 100% | finish no earlier than 2006-09-28 | 320 |
| 115 | 9.6 | Release 2 (transferred to maintenance schedule) |  | 1d? | 2006-03-17 A | 2006-03-17 A |  | 100% | start no earlier than 2006-03-17 |  |
| 117 | 10 | **Functional Preparation** |  | 259d? | 2004-05-04 A | 2005-04-29 A |  | 100% |  |  |
| 118 | 10.1 | Policy/Guideline/Procedure Review |  | 108d | 2004-05-04 A | 2004-09-30 A |  | 100% | start no earlier than 2004-05-04 |  |
| 119 | 10.2 | Preparation of Policy Issues for Universitywide Review |  | 88d? | 2004-09-30 A | 2005-01-31 A |  | 100% | finish no earlier than 2005-01-31 |  |
| 120 | 10.3 | Universitywide Policy Review |  | 130d? | 2004-11-01 A | 2005-04-29 A |  | 100% | finish no earlier than 2005-04-29 |  |
| 122 | 11 | **PPS and External Systems** |  | 540d? | 2004-03-02 A | 2006-03-27 A |  | 100% |  |  |
| 123 | 11.1 | Effort Percent Time |  | 45d | 2004-05-24 A | 2004-07-23 A |  | 100% | finish no earlier than 2004-07-31 |  |
| 124 | 11.2 | PPS Release 1591 available for campus install with effort percent time |  | 1d? | 2004-07-26 A | 2004-07-26 A |  | 100% | start no earlier than 2004-08-23 |  |
| 125 | 11.3 | ERS Extract Program Release - (R1694) SR16996 |  | 84d | 2005-11-01 A | 2006-02-24 A |  | 100% | finish no earlier than 2006-02-20 |  |
| 126 | 11.4 | **NIH Salary Cap** |  | 540d? | 2004-03-02 A | 2006-03-27 A |  | 100% |  |  |
| 127 | 11.4.1 | Requirements |  | 304d? | 2004-03-02 A | 2005-04-29 A |  | 100% | finish no earlier than 2005-04-29 |  |
| 128 | 11.4.2 | Base PPS Modifications - EDB Maintenance (R1647) SR16954 |  | 95d? | 2005-01-03 A | 2005-05-15 A |  | 100% | finish no earlier than 2005-05-15 |  |
| 129 | 11.4.3 | Salary Cap Reporting Fix (R1697) |  | 92d? | 2005-11-18 A | 2006-03-27 A |  | 100% | start no earlier than 2005-11-18 |  |
| 130 | 11.4.4 | Base PPS Modifications - Reporting (R1669) SR16979 |  | 107d? | 2005-06-01 A | 2005-10-27 A |  | 100% | finish no earlier than 2005-10-21 |  |
| 131 | 12 | Account/Fund Profile (CAFP) Enhancements (no changes necessary) |  | 67d? | 2005-06-01 A | 2005-09-01 A |  | 100% | finish no earlier than 2005-09-01 |  |
| 133 | 13 | Management Group Meetings |  | 465d? | 2004-07-01 A | 2006-04-12 A |  | 100% |  |  |
| 159 | 14 | Requirements Committee Meetings |  | 466d? | 2004-07-01 A | 2006-04-13 A |  | 100% |  |  |
| 184 | 15 | Technical Advisory Group Meetings |  | 446d? | 2004-08-03 A | 2006-04-18 A |  | 100% |  |  |

Notes:
- 110: Text1: System Technical Documentation
- 111: Text1: Source Inventories, Installation and Installation Verification Instructions, etc.
- 122: All PPS End Dates are Tentative Release Dates
- 123: (SR16931, SR16960)
- 126: Requirements In Progress; PPS Scheduling To Be Determined
