# ERS_Project_Schedule_20040804

Schedule from MS Project, 2004-03-02 to 2006-02-15, costs in $, A marks actual dates.
University of California

## Calendars

- Standard: Mon-Fri 08:00-12:00, 13:00-17:00; Sat-Sun off.

## Resources

| Resource | Rate |
| --- | --- |
| PM |  |
| LN | 75 |
| P1 | 95 |
| P2 | 90 |
| P3 | 90 |
| D1 | 75 |
| P4 | 95 |
| P5 | 90 |
| P6 | 90 |
| P7 | 90 |
| D1a | 90 |
| P8 | 90 |

## Schedule

| ID | WBS | Task | Duration | Start | Finish | Predecessors | Complete | Remaining | Total slack | Free slack | Constraint | Resources | Work | Actual work | Cost | Actual cost | Text2 | Text1 |
| --- | --- | --- | --- | --- | --- | --- | --- | --- | --- | --- | --- | --- | --- | --- | --- | --- | --- | --- |
| 1 | 1 | **Start-up** | 184d? | 2004-03-28 A | 2004-12-09 |  | 33% | 123.2d? | 309d |  |  |  |  |  |  |  |  |  |
| 2 | 1.1 | Identify Project Manager | 43d | 2004-03-28 A | 2004-05-26 A |  | 100% |  |  |  | finish no earlier than 2003-11-30 |  |  |  |  |  |  |  |
| 3 | 1.2 | Identify Liaison | 112d | 2004-03-28 A | 2004-08-31 |  | 10% | 101.25d | 381d |  | finish no earlier than 2004-08-31 |  |  |  |  |  |  |  |
| 4 | 1.3 | Identify other staff for start | 85d | 2004-04-26 A | 2004-08-20 |  | 32% | 57.5d | 388d |  | finish no earlier than 2004-08-20 |  |  |  |  |  |  |  |
| 6 | 1.4 | ERS Management Group Meetings | 116d? | 2004-07-01 A | 2004-12-09 |  | 22% | 90.22d? | 309d |  |  |  |  |  |  |  |  |  |
| 17 | 1.5 | Requirements Committee Meetings | 115d? | 2004-07-01 A | 2004-12-08 |  | 25% | 86.25d? | 310d |  |  |  |  |  |  |  |  |  |
| 27 | 1.6 | Technical Advisory Group Meetings | 1d? | 2004-08-03 | 2004-08-03 |  |  |  | 401d |  |  |  |  |  |  |  |  |  |
| 31 | 2 | **Architecture/Design** | 90d | 2004-07-19 A | 2004-11-19 |  |  | 89.58d | 323d |  |  |  | 2328h | 8h | 203,720 | 760 |  |  |
| 32 | 2.1 | **Application Code Design** | 32d | 2004-07-19 A | 2004-08-31 |  | 3% | 31d | 381d |  |  | P1 | 256h | 8h | 24,320 | 760 | 160 |  |
| 33 | 2.1.1 | PAR Processing | 25d | 2004-07-19 A | 2004-08-20 |  | 5% | 23.75d | 388d | 0d | start no earlier than 2004-07-19 |  |  |  |  |  |  |  |
| 34 | 2.1.2 | Security and roles processing | 15d | 2004-08-11 | 2004-08-31 | 33SS+17d |  |  | 381d |  | start no earlier than 2004-07-26 |  |  |  |  |  |  |  |
| 35 | 2.2 | **Database Design** | 45d | 2004-08-09 | 2004-10-08 |  |  |  | 353d |  |  | P3 | 360h |  | 32,400 |  | 480 |  |
| 36 | 2.2.1 | Data Element definition | 15d | 2004-08-09 | 2004-08-27 |  |  |  | 353d | 0d | start no earlier than 2004-08-09 |  |  |  |  |  |  |  |
| 37 | 2.2.2 | Data schema design | 30d | 2004-08-30 | 2004-10-08 | 36 |  |  | 353d |  |  |  |  |  |  |  |  |  |
| 38 | 2.3 | **Presentation Design - User** | 70d | 2004-08-16 | 2004-11-19 |  |  |  | 323d | 2d |  | D1 | 560h |  | 42,000 |  | 320 |  |
| 39 | 2.3.1 | Presentation user initial design | 35d | 2004-08-16 | 2004-10-01 |  |  |  | 323d | 0d | start no earlier than 2004-08-16 |  |  |  |  |  |  |  |
| 40 | 2.3.2 | Presentation user revised design | 35d | 2004-10-04 | 2004-11-19 | 39 |  |  | 323d |  |  |  |  |  |  |  |  |  |
| 41 | 2.4 | **Presentation Design - Administration** | 58d | 2004-09-01 | 2004-11-19 | 38SS+10d |  |  | 323d |  |  | D1a | 464h |  | 41,760 |  | 640 |  |
| 42 | 2.4.1 | Presentation Admin - initial design | 20d | 2004-09-01 | 2004-09-28 | 39SS+5d |  |  | 323d | 0d | start no earlier than 2004-09-01 |  |  |  |  |  |  |  |
| 43 | 2.4.2 | Presentation Admin - revised design | 38d | 2004-09-29 | 2004-11-19 | 42 |  |  | 323d |  |  |  |  |  |  |  |  |  |
| 44 | 2.5 | **Data Interfaces** | 53d | 2004-08-09 | 2004-10-20 |  |  |  | 345d |  |  | P1; P2 | 688h |  | 63,240 |  | 640 |  |
| 45 | 2.5.1 | Financial Data | 30d | 2004-08-09 | 2004-09-17 | 33SS+15d |  |  | 345d | 0d |  |  |  |  |  |  |  |  |
| 46 | 2.5.2 | Security and E-mail Systems | 25d | 2004-09-16 | 2004-10-20 | 45FS-2d |  |  | 345d |  |  |  |  |  |  |  |  |  |
| 48 | 3 | **Development** | 350d | 2004-09-06 | 2006-01-06 |  |  |  | 28d |  |  |  | 12000h |  | 1,088,400 |  |  |  |
| 49 | 3.1 | **Data Interfaces** | 150d | 2004-09-27 | 2005-04-22 |  |  |  | 213d |  |  |  | 1856h |  | 170,640 |  |  | Generic interfaces to local campus systems |
| 50 | 3.1.1 | Initial Data Load | 320h | 2004-09-27 | 2004-11-19 |  |  |  | 323d |  | start no earlier than 2004-09-26 | P4 | 320h |  | 30,400 |  |  |  |
| 51 | 3.1.2 | Payroll/Personnel System (PPS) | 200h | 2004-10-21 | 2004-11-24 |  |  |  | 320d |  |  | P2 | 200h |  | 18,000 |  | 160 | Payroll Audit Record |
| 52 | 3.1.3 | Financial Systems | 200h | 2004-11-25 | 2004-12-29 |  |  |  | 295d |  |  | P2 | 200h |  | 18,000 |  | 160 | Account/Fund Profile |
| 53 | 3.1.4 | Contracts & Grants | 200h | 2004-12-16 | 2005-01-19 |  |  |  | 280d |  |  | P3 | 200h |  | 18,000 |  | 160 |  |
| 54 | 3.1.5 | Cost Sharing | 320h | 2005-01-20 | 2005-03-16 |  |  |  | 240d |  |  | P3 | 320h |  | 28,800 |  | 160 |  |
| 55 | 3.1.6 | Authentication | 200h | 2004-11-01 | 2004-12-03 |  |  |  | 313d |  | start no earlier than 2004-10-31 | P1 | 200h |  | 19,000 |  | 160 | (Security System) |
| 56 | 3.1.7 | Authorization | 200h | 2004-12-06 | 2005-01-07 |  |  |  | 288d |  | start no earlier than 2004-12-05 | P1 | 200h |  | 19,000 |  | 160 | (Security System) |
| 57 | 3.1.8 | Email | 216h | 2005-03-17 | 2005-04-22 |  |  |  | 213d |  |  | P3 | 216h |  | 19,440 |  | 160 |  |
| 58 | 3.2 | Web Presentation | 640h | 2004-09-06 | 2004-12-24 |  |  |  | 298d |  | start no earlier than 2004-09-05 | D1; P3 | 960h |  | 79,200 |  | 480 | Detailed page layout, style sheets, graphics |
| 59 | 3.3 | Authorization Rules | 480h | 2005-01-03 | 2005-03-25 |  |  |  | 233d |  | start no earlier than 2005-01-02 | P1 | 480h |  | 45,600 |  | 480 | Implementation of roles and associated permissions |
| 60 | 3.4 | Authorizaton Administration | 480h | 2005-01-03 | 2005-03-25 |  |  |  | 233d |  | start no earlier than 2005-01-02 | P2 | 480h |  | 43,200 |  | 480 | Tool(s) for administration of roles and permissions |
| 61 | 3.5 | Web Navigation | 213.33h | 2004-12-27 | 2005-02-01 |  |  |  | 271.33d |  | start no earlier than 2004-12-26 | D1; P5 | 320h |  | 27,200 |  | 320 | General web navigation details for ERS |

| ID | WBS | Task | Duration | Start | Finish | Complete | Remaining | Total slack | Constraint | Resources | Work | Actual work | Cost | Actual cost | Text2 |
| --- | --- | --- | --- | --- | --- | --- | --- | --- | --- | --- | --- | --- | --- | --- | --- |
| 62 | 3.6 | **Effort Report Generation** | 205d | 2005-01-03 | 2005-10-14 |  |  | 88d |  |  | 1200h |  | 110,400 |  |  |
| 63 | 3.6.1 | Standard Report | 480h | 2005-01-03 | 2005-03-25 |  |  | 233d | start no earlier than 2005-01-02 | P4 | 480h |  | 45,600 |  | 480 |
| 64 | 3.6.2 | Exception | 480h | 2005-04-14 | 2005-07-06 |  |  | 160d |  | P3 | 480h |  | 43,200 |  | 480 |
| 65 | 3.6.3 | Reissuance | 240h | 2005-09-05 | 2005-10-14 |  |  | 88d |  | P2 | 240h |  | 21,600 |  | 240 |
| 66 | 3.7 | Notification Creation & Distribution | 320h | 2005-04-04 | 2005-05-27 |  |  | 188d | start no earlier than 2005-04-03 | P1 | 320h |  | 30,400 |  | 320 |
| 67 | 3.8 | Effort Report Search/Selection | 480h | 2005-01-31 | 2005-04-22 |  |  | 213d | start no earlier than 2005-01-30 | P5 | 480h |  | 43,200 |  | 480 |
| 68 | 3.9 | Online Effort Report Data Changes | 160h | 2005-07-07 | 2005-08-03 |  |  | 140d |  | P3 | 160h |  | 14,400 |  | 160 |
| 69 | 3.10 | Online Certifications | 160h | 2005-08-04 | 2005-08-31 |  |  | 120d |  | P3 | 160h |  | 14,400 |  | 160 |
| 70 | 3.11 | Multiple Certifications | 320h | 2005-09-01 | 2005-10-26 |  |  | 80d |  | P3 | 320h |  | 28,800 |  | 320 |
| 71 | 3.12 | Online Exception Data Collection/Modification | 480h | 2005-05-02 | 2005-07-22 |  |  | 148d | start no earlier than 2005-05-01 | P5 | 480h |  | 43,200 |  | 480 |
| 72 | 3.13 | Edits | 960h | 2005-03-28 | 2005-09-09 |  |  | 113d | start no earlier than 2005-03-27 | P2; P4 | 1544h |  | 141,960 |  | 1200 |
| 73 | 3.14 | Reminders | 200h | 2005-06-27 | 2005-07-29 |  |  | 143d | start no earlier than 2005-06-26 | P4 | 200h |  | 19,000 |  | 160 |
| 74 | 3.15 | Compliance Monitoring Tools* | 640h | 2005-05-19 | 2005-09-07 |  |  | 115d |  | P1 | 640h |  | 60,800 |  | 640 |
| 75 | 3.16 | Control/Audit Reports* | 480h | 2005-08-29 | 2005-11-18 |  |  | 63d | start no earlier than 2005-08-28 | P8 | 480h |  | 43,200 |  | 480 |
| 76 | 3.17 | General Reporting* | 960h | 2005-07-25 | 2006-01-06 |  |  | 28d | start no earlier than 2005-07-24 | P5 | 960h |  | 86,400 |  | 960 |
| 77 | 3.18 | Ad Hoc Reporting* | 960h | 2005-07-04 | 2005-12-16 |  |  | 43d | start no earlier than 2005-07-03 | P6 | 960h |  | 86,400 |  | 960 |
| 79 | 4 | **Testing** | 100d | 2005-08-22 | 2006-01-06 |  |  | 28d |  |  | 1280h |  | 117,600 |  |  |
| 80 | 4.1 | Application Testing | 664h | 2005-08-22 | 2005-12-14 |  |  | 45d | start no earlier than 2005-08-21 | P7; P4 | 960h |  | 88,800 |  | 960 |
| 81 | 4.2 | Load/Stress Testing | 320h | 2005-11-14 | 2006-01-06 |  |  | 28d | start no earlier than 2005-11-13 | P6 | 320h |  | 28,800 |  | 320 |
| 83 | 5 | **Deployment (Release to Campuses)** | 107d | 2005-09-08 | 2006-02-03 |  |  | 8d |  |  | 1120h |  | 104,000 |  |  |
| 84 | 5.1 | Documentation | 544h | 2005-09-08 | 2005-12-12 |  |  | 47d |  | P2; P1 | 640h |  | 59,200 |  | 640 |
| 85 | 5.2 | Technical Training | 320h | 2005-11-03 | 2005-12-28 |  |  | 35d |  | P1 | 320h |  | 30,400 |  | 320 |
| 86 | 5.3 | Deployment (Release) Packaging | 160h | 2006-01-09 | 2006-02-03 |  |  | 8d | start no earlier than 2006-01-08 | P3 | 160h |  | 14,400 |  | 160 |
| 88 | 6 | **Project Management** | 428d | 2004-06-28 A | 2006-02-15 | 4% | 408.76d | 0d |  |  | 4440h | 188.5h | 401,000 | 16,857.5 |  |
| 89 | 6.1 | Technical Project Management | 3400h | 2004-07-01 A | 2006-02-15 | 4% | 3264h | 0d |  | PM | 3400h | 136h | 323,000 | 12,920 | 3000 |
| 90 | 6.2 | Campus Coordination | 3322.5h | 2004-06-28 A | 2006-01-30 | 5% | 3156.38h | 12.69d | start no earlier than 2004-06-27 | LN | 1040h | 52.5h | 78,000 | 3,937.5 | 1000 |

Notes:
- 63: Text1: Standard generation (batch and one-time) of the Effort Report
- 64: Text1: Generation of effort reports for previously excluded or terminating employees
- 65: Text1: re-generation of effort reports when changes in effort meet threshhold requirements for re-certification
- 66: Text1: Mechanism for notifying individuals that effort reports are ready for pre-review, review/certification, or have been certified
- 67: Text1: Mechanism for locating effort reports (general search, role-based search, etc.)
- 68: Text1: Mechanism for changing effort detail on an individual effort report
- 69: Text1: Mechanism for certifying one effort report
- 70: Text1: Mechanism for certifying two or more effort reports at one time
- 71: Text1: Mechanism for collecting data on individuals who received no pay from a sponsored project
- 72: Text1: Various edits on data from incoming interface files and data entered online
- 73: Text1: Mechanism for providing reminders of needed reviews and certifications
- 74: Text1: Reports for measuring current period compliance and comparing with historical periods
- 75: Text1: System-level controls and audit reports(e.g., system access reports, transaction statistics)
- 76: Text1: Standard reporting other than compliance/control/audit reporting (needs detailed definition)
- 77: Text1: (if other than third-party tools-based reporting)
- 81: Text1: Stress testing to determine system performance characteristics
- 84: Text1: System Technical Documentation
- 86: Text1: Source Inventories, Installation and Installation Verification Instructions, etc.
- 89: Text1: Day-to-day technical project management
- 90: Text1: Coordination of campus staff participating in resolving requirements/development issues, system testing, etc.

| ID | WBS | Task | Duration | Start | Finish | Complete | Remaining | Total slack | Constraint |
| --- | --- | --- | --- | --- | --- | --- | --- | --- | --- |
| 92 | 7 | **Functional Preparation** | 436d? | 2004-05-04 A | 2006-01-03 | 10% | 392.61d? | 31d |  |
| 93 | 7.1 | Policy/Guideline/Procedure Review | 108d | 2004-05-04 A | 2004-09-30 | 50% | 54d | 359d | start no earlier than 2004-05-04 |
| 94 | 7.2 | Preparation of Policy Issues for Universitywide Review | 22d? | 2004-09-30 | 2004-10-31 |  |  | 338d | finish no earlier than 2004-10-31 |
| 95 | 7.3 | Universitywide Policy Review | 66d? | 2004-11-01 | 2005-01-31 |  |  | 272d | finish no earlier than 2005-01-31 |
| 96 | 7.4 | End-User Training Strategy | 80d | 2004-05-10 A | 2004-08-27 | 10% | 72d | 383d | start no earlier than 2004-05-09 |
| 97 | 7.5 | Common End-User Training Development | 347d | 2004-09-06 | 2006-01-03 |  |  | 31d | start no earlier than 2004-09-05 |
| 99 | 8 | **PPS Activities (Finish Dates Tentative)** | 314d? | 2004-03-02 A | 2005-05-15 | 52% | 151.13d? | 198d |  |
| 100 | 8.1 | Effort Percent Time | 50d | 2004-05-24 A | 2004-07-31 A | 100% |  |  | finish no earlier than 2004-07-31 |
| 101 | 8.2 | **NIH Salary Cap** | 314d? | 2004-03-02 A | 2005-05-15 | 40% | 188.17d? | 198d |  |
| 102 | 8.2.1 | Requirements | 109d? | 2004-03-02 A | 2004-07-31 | 75% | 27.25d? | 403d | finish no earlier than 2004-07-31 |
| 103 | 8.2.2 | Base PPS Modifications | 95d? | 2005-01-03 | 2005-05-15 |  |  | 198d | finish no earlier than 2005-05-15 |

Notes:
- 99: All PPS End Dates are Tentative Release Dates
- 100: (SR16931, SR16960) PPS Work Is In Progress
- 101: Requirements In Progress; PPS Scheduling To Be Determined
