# ERS_Project_Schedule_20040804

Schedule from MS Project, 2004-03-02 to 2006-02-15, costs in $, A marks actual dates.
University of California
updated 8/26

## Calendars

- Standard: Mon-Fri 08:00-12:00, 13:00-17:00; Sat-Sun off.

## Resources

| Resource | Rate |
| --- | --- |
| PM | 95 |
| LN | 75 |
| P1 | 95 |
| P2 | 90 |
| P3 | 90 |
| D1 | 75 |
| P4 | 95 |
| P5 | 90 |
| P6 | 90 |
| P7 | 90 |
| D1a | 90 |
| P8 | 90 |

## Schedule

| ID | WBS | Task | Duration | Start | Finish | Predecessors | Complete | Remaining | Total slack | Free slack | Constraint | Resources | Work | Actual work | Cost | Actual cost | Text2 |
| --- | --- | --- | --- | --- | --- | --- | --- | --- | --- | --- | --- | --- | --- | --- | --- | --- | --- |
| 1 | 1 | **Start-up** | 112d | 2004-03-28 A | 2004-08-31 |  | 34% | 74.08d | 381d |  |  |  |  |  |  |  |  |
| 2 | 1.1 | Identify Project Manager | 43d | 2004-03-28 A | 2004-05-26 A |  | 100% |  |  |  | finish no earlier than 2003-11-30 |  |  |  |  |  |  |
| 3 | 1.2 | Identify Liaison | 112d | 2004-03-28 A | 2004-08-31 |  | 10% | 101.25d | 381d |  | finish no earlier than 2004-08-31 |  |  |  |  |  |  |
| 4 | 1.3 | Identify other staff for start | 85d | 2004-04-26 A | 2004-08-20 |  | 32% | 57.5d | 388d |  | finish no earlier than 2004-08-20 |  |  |  |  |  |  |
| 6 | 2 | ERS Management Group Meetings | 116d? | 2004-07-01 A | 2004-12-09 |  | 44% | 64.44d? | 309d |  |  |  |  |  |  |  |  |
| 17 | 3 | Requirements Committee Meetings | 115d? | 2004-07-01 A | 2004-12-08 |  | 50% | 57.5d? | 310d |  |  |  |  |  |  |  |  |
| 27 | 4 | Technical Advisory Group Meetings | 46d? | 2004-08-03 A | 2004-10-05 |  | 50% | 23d? | 356d |  |  |  |  |  |  |  |  |
| 33 | 5 | **Architecture/Design** | 155.5d? | 2004-07-19 A | 2005-02-21 |  | 12% | 136.78d? | 257.5d |  |  |  | 3348h | 166.48h | 292,460 | 14,949.44 |  |
| 34 | 5.1 | **Application Code Design** | 50d | 2004-07-19 A | 2004-09-24 |  | 48% | 25.94d | 363d |  |  | P1 | 400h | 96.6h | 38,000 | 9,176.84 | 160 |
| 35 | 5.1.1 | PAR Processing | 50d | 2004-07-19 A | 2004-09-24 |  | 35% | 32.5d | 294.5d | 0d | start no earlier than 2004-07-19 |  |  |  |  |  |  |
| 36 | 5.1.2 | Security and roles processing | 30d | 2004-08-11 A | 2004-09-21 | 35SS+17d | 70% | 9d | 366d |  | start no earlier than 2004-07-26 |  |  |  |  |  |  |
| 37 | 5.2 | **Database Design** | 81d? | 2004-09-13 A | 2005-01-03 |  | 2% | 79.35d? | 292d |  |  | P3 | 648h | 13.2h | 58,320 | 1,188 | 480 |
| 38 | 5.2.1 | Hire Data Base Designer | 11d? | 2004-09-13 A | 2004-09-27 |  | 15% | 9.35d? | 292d | 0d | finish no earlier than 2004-09-27 |  |  |  |  |  |  |
| 39 | 5.2.2 | Data Element definition | 20d | 2004-09-28 | 2004-10-25 | 38 |  |  | 292d | 0d | start no earlier than 2004-08-09 |  |  |  |  |  |  |
| 40 | 5.2.3 | Define Batch extract schema | 20d | 2004-10-26 | 2004-11-22 | 39 |  |  | 292d | 0d |  |  |  |  |  |  |  |
| 41 | 5.2.4 | Data schema design | 30d | 2004-11-23 | 2005-01-03 | 40 |  |  | 292d |  |  |  |  |  |  |  |  |
| 42 | 5.3 | **Presentation Design - User** | 107.5d | 2004-08-16 A | 2005-01-12 |  | 4% | 102.85d | 178.83d | 67.5d |  | D1 | 860h | 37.16h | 64,500 | 2,787 | 320 |
| 43 | 5.3.1 | Hire Graphics consultant | 11d | 2004-09-27 | 2004-10-11 |  |  |  | 178.83d | 0d | finish no earlier than 2004-10-11 |  |  |  |  |  |  |
| 44 | 5.3.2 | Presentation user initial design | 35d | 2004-08-16 A | 2004-11-24 | 43 | 10% | 31.5d | 178.83d | 0d | start no earlier than 2004-08-16 |  |  |  |  |  |  |
| 45 | 5.3.3 | Presentation user revised design | 35d | 2004-11-24 | 2005-01-12 | 44 |  |  | 178.83d | 0d |  |  |  |  |  |  |  |
| 46 | 5.4 | **Presentation Design - Administration** | 58d | 2004-12-01 | 2005-02-21 | 42SS+10d |  |  | 257.5d |  |  | D1a | 464h |  | 41,760 |  | 640 |
| 47 | 5.4.1 | Presentation Admin - initial design | 20d | 2004-12-01 | 2004-12-29 | 44FS+5d, 43 |  |  | 257.5d | 0d | start no earlier than 2004-09-01 |  |  |  |  |  |  |
| 48 | 5.4.2 | Presentation Admin - revised design | 38d | 2004-12-29 | 2005-02-21 | 47 |  |  | 257.5d |  |  |  |  |  |  |  |  |
| 49 | 5.5 | **Data Interfaces** | 71d | 2004-09-13 A | 2004-12-20 |  | 2% | 69.58d | 302d |  |  | P1; P2 | 976h | 19.52h | 89,880 | 1,797.6 | 640 |
| 50 | 5.5.1 | Financial Data | 30d | 2004-09-13 A | 2004-11-05 | 35, 38 | 5% | 28.5d | 308.5d | 0d |  |  |  |  |  |  |  |
| 51 | 5.5.2 | Security and E-mail Systems | 25d | 2004-11-05 | 2004-12-10 | 50 |  |  | 308.5d |  |  |  |  |  |  |  |  |
| 52 | 5.5.3 | PPS/PAR System Extracts | 20d | 2004-11-23 | 2004-12-20 | 38, 39, 40 |  |  | 302d |  |  |  |  |  |  |  |  |

| ID | WBS | Task | Duration | Start | Finish | Predecessors | Total slack | Free slack | Constraint | Resources | Work | Cost | Text2 |
| --- | --- | --- | --- | --- | --- | --- | --- | --- | --- | --- | --- | --- | --- |
| 54 | 6 | **Development** | 310d | 2004-11-01 | 2006-01-06 |  | 28d |  |  |  | 12000h | 1,088,400 |  |
| 55 | 6.1 | **Data Interfaces** | 125d | 2004-11-01 | 2005-04-22 |  | 213d |  |  |  | 1856h | 170,640 |  |
| 56 | 6.1.1 | Initial Data Load | 320h | 2004-12-07 | 2005-01-31 | 52SS+10d, 40 | 272d |  | start no earlier than 2004-09-26 | P4 | 320h | 30,400 |  |
| 57 | 6.1.2 | Payroll/Personnel System (PPS) | 200h | 2004-11-30 | 2005-01-03 | 52SS+5d | 292d |  |  | P2 | 200h | 18,000 | 160 |
| 58 | 6.1.3 | Financial Systems | 200h | 2004-11-25 | 2004-12-29 |  | 295d |  |  | P2 | 200h | 18,000 | 160 |
| 59 | 6.1.4 | Contracts & Grants | 200h | 2004-12-16 | 2005-01-19 |  | 280d |  |  | P3 | 200h | 18,000 | 160 |
| 60 | 6.1.5 | Cost Sharing | 320h | 2005-01-20 | 2005-03-16 |  | 240d |  |  | P3 | 320h | 28,800 | 160 |
| 61 | 6.1.6 | Authentication | 200h | 2004-11-01 | 2004-12-03 |  | 313d |  | start no earlier than 2004-10-31 | P1 | 200h | 19,000 | 160 |
| 62 | 6.1.7 | Authorization | 200h | 2004-12-06 | 2005-01-07 |  | 288d |  | start no earlier than 2004-12-05 | P1 | 200h | 19,000 | 160 |
| 63 | 6.1.8 | Email | 216h | 2005-03-17 | 2005-04-22 |  | 213d |  |  | P3 | 216h | 19,440 | 160 |
| 64 | 6.2 | Web Presentation | 640h | 2005-01-12 | 2005-05-04 | 43, 45 | 178.83d | 0d | start no earlier than 2004-09-05 | D1; P3 | 960h | 79,200 | 480 |
| 65 | 6.3 | Authorization Rules | 480h | 2005-01-03 | 2005-03-25 |  | 233d |  | start no earlier than 2005-01-02 | P1 | 480h | 45,600 | 480 |
| 66 | 6.4 | Authorizaton Administration | 480h | 2005-01-03 | 2005-03-25 |  | 233d |  | start no earlier than 2005-01-02 | P2 | 480h | 43,200 | 480 |
| 67 | 6.5 | Web Navigation | 213.33h | 2005-05-04 | 2005-06-10 | 64 | 178.83d |  | start no earlier than 2004-12-26 | D1; P5 | 320h | 27,200 | 320 |
| 68 | 6.6 | **Effort Report Generation** | 205d | 2005-01-03 | 2005-10-14 |  | 88d |  |  |  | 1200h | 110,400 |  |
| 69 | 6.6.1 | Standard Report | 480h | 2005-01-03 | 2005-03-25 |  | 233d |  | start no earlier than 2005-01-02 | P4 | 480h | 45,600 | 480 |
| 70 | 6.6.2 | Exception | 480h | 2005-04-14 | 2005-07-06 |  | 160d |  |  | P3 | 480h | 43,200 | 480 |
| 71 | 6.6.3 | Reissuance | 240h | 2005-09-05 | 2005-10-14 |  | 88d |  |  | P2 | 240h | 21,600 | 240 |
| 72 | 6.7 | Notification Creation & Distribution | 320h | 2005-04-04 | 2005-05-27 |  | 188d |  | start no earlier than 2005-04-03 | P1 | 320h | 30,400 | 320 |
| 73 | 6.8 | Effort Report Search/Selection | 480h | 2005-01-31 | 2005-04-22 |  | 213d |  | start no earlier than 2005-01-30 | P5 | 480h | 43,200 | 480 |
| 74 | 6.9 | Online Effort Report Data Changes | 160h | 2005-07-07 | 2005-08-03 |  | 140d |  |  | P3 | 160h | 14,400 | 160 |
| 75 | 6.10 | Online Certifications | 160h | 2005-08-04 | 2005-08-31 |  | 120d |  |  | P3 | 160h | 14,400 | 160 |
| 76 | 6.11 | Multiple Certifications | 320h | 2005-09-01 | 2005-10-26 |  | 80d |  |  | P3 | 320h | 28,800 | 320 |
| 77 | 6.12 | Online Exception Data Collection/Modification | 480h | 2005-05-02 | 2005-07-22 |  | 148d |  | start no earlier than 2005-05-01 | P5 | 480h | 43,200 | 480 |
| 78 | 6.13 | Edits | 960h | 2005-03-28 | 2005-09-09 |  | 113d |  | start no earlier than 2005-03-27 | P2; P4 | 1544h | 141,960 | 1200 |
| 79 | 6.14 | Reminders | 200h | 2005-06-27 | 2005-07-29 |  | 143d |  | start no earlier than 2005-06-26 | P4 | 200h | 19,000 | 160 |
| 80 | 6.15 | Compliance Monitoring Tools* | 640h | 2005-05-19 | 2005-09-07 |  | 115d |  |  | P1 | 640h | 60,800 | 640 |
| 81 | 6.16 | Control/Audit Reports* | 480h | 2005-08-29 | 2005-11-18 |  | 63d |  | start no earlier than 2005-08-28 | P8 | 480h | 43,200 | 480 |
| 82 | 6.17 | General Reporting* | 960h | 2005-07-25 | 2006-01-06 |  | 28d |  | start no earlier than 2005-07-24 | P5 | 960h | 86,400 | 960 |
| 83 | 6.18 | Ad Hoc Reporting* | 960h | 2005-07-04 | 2005-12-16 |  | 43d |  | start no earlier than 2005-07-03 | P6 | 960h | 86,400 | 960 |

Notes:
- 55: Text1: Generic interfaces to local campus systems
- 57: Text1: Payroll Audit Record
- 58: Text1: Account/Fund Profile
- 61: Text1: (Security System)
- 62: Text1: (Security System)
- 64: Text1: Detailed page layout, style sheets, graphics
- 65: Text1: Implementation of roles and associated permissions
- 66: Text1: Tool(s) for administration of roles and permissions
- 67: Text1: General web navigation details for ERS
- 69: Text1: Standard generation (batch and one-time) of the Effort Report
- 70: Text1: Generation of effort reports for previously excluded or terminating employees
- 71: Text1: re-generation of effort reports when changes in effort meet threshhold requirements for re-certification
- 72: Text1: Mechanism for notifying individuals that effort reports are ready for pre-review, review/certification, or have been certified
- 73: Text1: Mechanism for locating effort reports (general search, role-based search, etc.)
- 74: Text1: Mechanism for changing effort detail on an individual effort report
- 75: Text1: Mechanism for certifying one effort report
- 76: Text1: Mechanism for certifying two or more effort reports at one time
- 77: Text1: Mechanism for collecting data on individuals who received no pay from a sponsored project
- 78: Text1: Various edits on data from incoming interface files and data entered online
- 79: Text1: Mechanism for providing reminders of needed reviews and certifications
- 80: Text1: Reports for measuring current period compliance and comparing with historical periods
- 81: Text1: System-level controls and audit reports(e.g., system access reports, transaction statistics)
- 82: Text1: Standard reporting other than compliance/control/audit reporting (needs detailed definition)
- 83: Text1: (if other than third-party tools-based reporting)

| ID | WBS | Task | Duration | Start | Finish | Complete | Remaining | Total slack | Constraint | Resources | Work | Actual work | Cost | Actual cost | Text2 |
| --- | --- | --- | --- | --- | --- | --- | --- | --- | --- | --- | --- | --- | --- | --- | --- |
| 85 | 7 | **Testing** | 100d | 2005-08-22 | 2006-01-06 |  |  | 28d |  |  | 1280h |  | 117,600 |  |  |
| 86 | 7.1 | Application Testing | 664h | 2005-08-22 | 2005-12-14 |  |  | 45d | start no earlier than 2005-08-21 | P7; P4 | 960h |  | 88,800 |  | 960 |
| 87 | 7.2 | Load/Stress Testing | 320h | 2005-11-14 | 2006-01-06 |  |  | 28d | start no earlier than 2005-11-13 | P6 | 320h |  | 28,800 |  | 320 |
| 89 | 8 | **Deployment (Release to Campuses)** | 107d | 2005-09-08 | 2006-02-03 |  |  | 8d |  |  | 1120h |  | 104,000 |  |  |
| 90 | 8.1 | Documentation | 544h | 2005-09-08 | 2005-12-12 |  |  | 47d |  | P2; P1 | 640h |  | 59,200 |  | 640 |
| 91 | 8.2 | Technical Training | 320h | 2005-11-03 | 2005-12-28 |  |  | 35d |  | P1 | 320h |  | 30,400 |  | 320 |
| 92 | 8.3 | Deployment (Release) Packaging | 160h | 2006-01-09 | 2006-02-03 |  |  | 8d | start no earlier than 2006-01-08 | P3 | 160h |  | 14,400 |  | 160 |
| 94 | 9 | **Project Management** | 428d | 2004-06-28 A | 2006-02-15 | 4% | 408.76d | 0d |  |  | 4440h | 188.5h | 401,000 | 16,857.5 |  |
| 95 | 9.1 | Technical Project Management | 3400h | 2004-07-01 A | 2006-02-15 | 4% | 3264h | 0d |  | PM | 3400h | 136h | 323,000 | 12,920 | 3000 |
| 96 | 9.2 | Campus Coordination | 3322.5h | 2004-06-28 A | 2006-01-30 | 5% | 3156.38h | 12.69d | start no earlier than 2004-06-27 | LN | 1040h | 52.5h | 78,000 | 3,937.5 | 1000 |
| 98 | 10 | **Functional Preparation** | 436d? | 2004-05-04 A | 2006-01-03 | 10% | 391.32d? | 31d |  |  |  |  |  |  |  |
| 99 | 10.1 | Policy/Guideline/Procedure Review | 108d | 2004-05-04 A | 2004-09-30 | 50% | 54d | 359d | start no earlier than 2004-05-04 |  |  |  |  |  |  |
| 100 | 10.2 | Preparation of Policy Issues for Universitywide Review | 22d? | 2004-09-30 A | 2004-10-31 | 20% | 17.6d? | 338d | finish no earlier than 2004-10-31 |  |  |  |  |  |  |
| 101 | 10.3 | Universitywide Policy Review | 66d? | 2004-11-01 | 2005-01-31 |  |  | 272d | finish no earlier than 2005-01-31 |  |  |  |  |  |  |
| 102 | 10.4 | End-User Training Strategy | 105d | 2004-05-10 A | 2004-10-01 | 8% | 97d | 358d | finish no earlier than 2004-10-01 |  |  |  |  |  |  |
| 103 | 10.5 | Common End-User Training Development | 347d | 2004-09-06 | 2006-01-03 |  |  | 31d | start no earlier than 2004-09-05 |  |  |  |  |  |  |
| 105 | 11 | **PPS Activities (Finish Dates Tentative)** | 314d? | 2004-03-02 A | 2005-05-15 | 41% | 186.66d? | 198d |  |  |  |  |  |  |  |
| 106 | 11.1 | Effort Percent Time | 45d | 2004-05-24 A | 2004-07-23 A | 100% |  |  | finish no earlier than 2004-07-31 |  |  |  |  |  |  |
| 107 | 11.2 | PPS Release 1591 available for campus install with effort percent time | 1d? | 2004-07-26 A | 2004-07-26 A | 100% |  |  | start no earlier than 2004-08-23 |  |  |  |  |  |  |
| 108 | 11.3 | **NIH Salary Cap** | 314d? | 2004-03-02 A | 2005-05-15 | 30% | 218.57d? | 198d |  |  |  |  |  |  |  |
| 109 | 11.3.1 | Requirements | 174d? | 2004-03-02 A | 2004-10-29 | 47% | 92.25d? | 338d | finish no earlier than 2004-10-29 |  |  |  |  |  |  |
| 110 | 11.3.2 | Base PPS Modifications | 95d? | 2005-01-03 | 2005-05-15 |  |  | 198d | finish no earlier than 2005-05-15 |  |  |  |  |  |  |

Notes:
- 87: Text1: Stress testing to determine system performance characteristics
- 90: Text1: System Technical Documentation
- 92: Text1: Source Inventories, Installation and Installation Verification Instructions, etc.
- 95: Text1: Day-to-day technical project management
- 96: Text1: Coordination of campus staff participating in resolving requirements/development issues, system testing, etc.
- 105: All PPS End Dates are Tentative Release Dates
- 106: (SR16931, SR16960)
- 108: Requirements In Progress; PPS Scheduling To Be Determined
